# REVISI 1

Schedule from MS Project, 2024-08-01 to 2025-02-03, costs in Rp, A marks actual dates.

## Calendars

- Standard: Mon-Sun 08:00-12:00, 13:00-17:00.

## Resources

| Resource | Rate | Cost per use |
| --- | --- | --- |
| Mandor | 21250 |  |
| Tukang | 21250 |  |
| Pembantu Tukang | 15000 |  |
| Subkon 1 | 21250 | 1000000 |
| Subkon 2 |  | 200000 |
| Subkon 3 |  | 1200000 |
| Subkon 4 |  | 350000 |
| Subkon 5 |  | 3000000 |
| Subkon 6 |  | 240000 |
| Subkon 7 |  | 3000000 |

## Schedule

| ID | WBS | Task | Type | Duration | Start | Finish | Predecessors | Complete | Remaining | Total slack | Free slack | Constraint | Resources | Work | Actual work | Cost | Actual cost |
| --- | --- | --- | --- | --- | --- | --- | --- | --- | --- | --- | --- | --- | --- | --- | --- | --- | --- |
| 1 | 1 | **project 1 Rumah tinggal** |  | 187d | 2024-08-01 A | 2025-02-03 |  | 1% | 185.02d | 0d |  |  |  | 8400h | 72h | 165,800,000 | 1,510,000 |
| 2 | 1.1 | **PekerjaanPersiapan** |  | 3d | 2024-08-01 A | 2024-08-03 A |  | 100% |  |  |  |  |  | 72h | 72h | 1,510,000 | 1,510,000 |
| 3 | 1.1.1 | Pembersihan lahan, Pengukuran dan pasang bouwplank |  | 2d | 2024-08-01 A | 2024-08-02 A |  | 100% |  |  |  |  | Mandor; Pembantu Tukang [200%]; Tukang | 64h | 64h | 1,160,000 | 1,160,000 |
| 4 | 1.1.2 | Bor Sumur |  | 1d | 2024-08-03 A | 2024-08-03 A | 3 | 100% |  |  |  |  | Subkon 4 | 8h | 8h | 350,000 | 350,000 |
| 5 | 1.2 | **Pekerjaan Pembesian** |  | 7d | 2024-08-03 | 2024-08-09 |  |  |  | 0d |  |  | Mandor | 600h |  | 12,750,000 |  |
| 6 | 1.2.1 | Pembesian cakar ayam |  | 3d | 2024-08-03 | 2024-08-05 | 3 |  |  | 0d |  |  | Tukang [200%] | 48h |  | 1,020,000 |  |
| 7 | 1.2.2 | Pembesian sloof dan kolom |  | 7d | 2024-08-03 | 2024-08-09 | 6SS |  |  | 8d | 0d |  | Tukang [200%] | 112h |  | 2,380,000 |  |
| 8 | 1.2.3 | Pembesian Balok | manual | 5d | 2024-08-03 | 2024-08-07 | 7SS |  |  |  |  |  | Tukang [400%] | 160h |  | 3,400,000 |  |
| 9 | 1.2.4 | Pembesian dak talang |  | 5d | 2024-08-03 | 2024-08-07 | 7SS |  |  | 88d | 0d |  | Tukang [200%] | 80h |  | 1,700,000 |  |
| 10 | 1.2.5 | Pembesian balok ring |  | 3d | 2024-08-03 | 2024-08-05 | 9SS |  |  | 118d | 0d |  | Tukang [200%] | 48h |  | 1,020,000 |  |
| 11 | 1.2.6 | Pembesian balok gewel |  | 2d | 2024-08-03 | 2024-08-04 | 10SS |  |  | 118d | 0d |  | Tukang [200%] | 32h |  | 680,000 |  |
| 12 | 1.2.7 | Pembesian balok latai |  | 1d | 2024-08-03 | 2024-08-03 | 11SS |  |  | 182d | 0d |  | Tukang [200%] | 16h |  | 340,000 |  |
| 13 | 1.2.8 | Pembesian pilar an balok carport |  | 3d | 2024-08-03 | 2024-08-05 | 12SS |  |  | 182d |  |  | Tukang [200%] | 48h |  | 1,020,000 |  |
| 14 | 1.3 | **Pekerjaan Tanah** |  | 12d | 2024-08-06 | 2024-08-17 |  |  |  | 0d |  |  | Mandor | 384h |  | 7,510,000 |  |
| 15 | 1.3.1 | Pondasi Cakar ayam |  | 2d | 2024-08-06 | 2024-08-07 | 6 |  |  | 0d |  |  | Tukang [200%] | 32h |  | 680,000 |  |
| 16 | 1.3.2 | Galian pondasi |  | 2d | 2024-08-08 | 2024-08-09 | 15 |  |  | 0d |  |  | Pembantu Tukang [200%] | 32h |  | 480,000 |  |
| 17 | 1.3.3 | Pasang pondasi batu kali |  | 3d | 2024-08-10 | 2024-08-12 | 16 |  |  | 0d |  |  | Tukang [200%]; Pembantu Tukang [200%] | 96h |  | 1,740,000 |  |
| 18 | 1.3.4 | Rollag anak tangga teras depan dan belakang |  | 3d | 2024-08-13 | 2024-08-15 | 17 |  |  | 0d |  |  | Tukang; Pembantu Tukang | 48h |  | 870,000 |  |
| 19 | 1.3.5 | Urugan tanah pondasi |  | 5d | 2024-08-13 | 2024-08-17 | 18SS |  |  | 0d |  |  | Tukang [200%] | 80h |  | 1,700,000 |  |
| 20 | 1.4 | **Instalasi air kotor** |  | 2d | 2024-08-13 | 2024-08-14 |  |  |  | 173d |  |  | Mandor | 96h |  | 1,790,000 |  |
| 21 | 1.4.1 | Instal air kotor |  | 2d | 2024-08-13 | 2024-08-14 | 17 |  |  | 173d | 0d | start no earlier than 2024-08-13 | Tukang; Pembantu Tukang | 32h |  | 580,000 |  |
| 22 | 1.4.2 | Pembuatan bak kontrol |  | 1d | 2024-08-13 | 2024-08-13 | 21SS |  |  | 173d | 0d |  | Tukang; Pembantu Tukang | 16h |  | 290,000 |  |
| 23 | 1.4.3 | Pasang bio sepictank |  | 2d | 2024-08-13 | 2024-08-14 | 22SS |  |  | 173d |  |  | Tukang; Pembantu Tukang | 32h |  | 580,000 |  |
| 24 | 1.5 | **Pekerjaan Beton** |  | 119d | 2024-08-18 | 2024-12-14 |  |  |  | 0d |  |  | Mandor | 4552h |  | 85,130,000 |  |
| 25 | 1.5.1 | Cor sloof |  | 7d | 2024-08-18 | 2024-08-24 | 19, 7 |  |  | 0d |  |  | Tukang [200%]; Pembantu Tukang [200%] | 224h |  | 4,060,000 |  |
| 26 | 1.5.2 | Cor Sloof Double |  | 7d | 2024-08-25 | 2024-08-31 | 25, 7 |  |  | 0d |  |  | Tukang [200%]; Pembantu Tukang [200%] | 224h |  | 4,060,000 |  |
| 27 | 1.5.3 | Cor Kolom |  | 24d | 2024-09-01 | 2024-09-24 | 26, 7 |  |  | 0d |  |  | Tukang; Pembantu Tukang | 384h |  | 6,960,000 |  |
| 28 | 1.5.4 | Cor Balok |  | 23d | 2024-09-25 | 2024-10-17 | 27, 8 |  |  | 0d |  |  | Tukang [200%]; Pembantu Tukang [200%] | 736h |  | 13,340,000 |  |
| 29 | 1.5.5 | Cor Balok Double |  | 17d | 2024-10-18 | 2024-11-03 | 28, 8 |  |  | 0d |  |  | Tukang [200%]; Pembantu Tukang [200%] | 544h |  | 9,860,000 |  |
| 30 | 1.5.6 | Cor dak talang |  | 20d | 2024-11-04 | 2024-11-23 | 29, 9 |  |  | 0d |  |  | Tukang [200%]; Pembantu Tukang [200%] | 640h |  | 11,600,000 |  |
| 31 | 1.5.7 | Cor Dak kanopi |  | 7d | 2024-11-24 | 2024-11-30 | 30 |  |  | 0d |  |  | Tukang [200%]; Pembantu Tukang [200%] | 224h |  | 4,060,000 |  |
| 32 | 1.5.8 | Cor balok gewel |  | 14d | 2024-12-01 | 2024-12-14 | 31, 11 |  |  | 0d |  |  | Tukang [200%]; Pembantu Tukang [300%] | 560h |  | 9,800,000 |  |
| 33 | 1.5.9 | Cor Balok ring | manual | 2d | 2024-09-08 | 2024-09-09 | 35, 10 |  |  |  |  |  | Tukang [200%]; Pembantu Tukang [200%] | 64h |  | 1,160,000 |  |

| ID | WBS | Task | Duration | Start | Finish | Predecessors | Total slack | Free slack | Resources | Work | Cost |
| --- | --- | --- | --- | --- | --- | --- | --- | --- | --- | --- | --- |
| 34 | 1.6 | **Pekerjaan Pasangan** | 10d | 2024-09-10 | 2024-09-19 |  | 80d |  | Mandor | 360h | 6,600,000 |
| 35 | 1.6.1 | Pasangan bata ringan | 7d | 2024-09-13 | 2024-09-19 | 26, 27SS+5% | 77d | 0d | Tukang; Pembantu Tukang | 112h | 2,030,000 |
| 36 | 1.6.2 | Pasang bata gewel | 7d | 2024-09-10 | 2024-09-16 | 33 | 89d |  | Tukang; Pembantu Tukang [200%] | 168h | 2,870,000 |
| 37 | 1.7 | **Pekerjaan Atap** | 6d | 2024-12-15 | 2024-12-20 |  | 0d |  |  | 144h | 3,810,000 |
| 38 | 1.7.1 | Pasang rangka atap/ galvalum | 4d | 2024-12-15 | 2024-12-18 | 35, 36, 32, 33 | 0d |  | Subkon 1 | 32h | 1,680,000 |
| 39 | 1.7.2 | Pasang genteng | 1d | 2024-12-19 | 2024-12-19 | 38 | 0d |  | Mandor; Tukang [200%]; Pembantu Tukang [300%] | 48h | 870,000 |
| 40 | 1.7.3 | Plester aci nok dan jurai genteng | 2d | 2024-12-19 | 2024-12-20 | 39SS | 0d |  | Mandor; Tukang [200%]; Pembantu Tukang | 64h | 1,260,000 |
| 41 | 1.8 | **Instalasi air bersih** | 2d | 2024-12-20 | 2024-12-21 | 39 | 44d | 0d |  | 16h | 340,000 |
| 42 | 1.8.1 | Instal air bersih | 2d | 2024-12-20 | 2024-12-21 |  | 44d |  | Tukang | 16h | 340,000 |
| 43 | 1.9 | **Instalasi listrik** | 3d | 2024-12-20 | 2024-12-22 | 41SS | 43d |  |  | 24h | 3,000,000 |
| 44 | 1.9.1 | Instal listrik 50% | 3d | 2024-12-20 | 2024-12-22 |  | 43d |  | Subkon 7 | 24h | 3,000,000 |
| 45 | 1.10 | **Pekerjaan Plesteran** | 29d | 2024-12-21 | 2025-01-18 |  | 0d |  |  | 1184h | 22,590,000 |
| 46 | 1.10.1 | Plester, render & skim tampak depan samping dan belakang | 14d | 2024-12-21 | 2025-01-03 | 40 | 0d |  | Mandor; Tukang [200%]; Pembantu Tukang [300%] | 672h | 12,180,000 |
| 47 | 1.10.2 | Render | 3d | 2025-01-04 | 2025-01-06 | 46 | 0d |  | Mandor; Tukang [200%]; Pembantu Tukang [300%] | 144h | 2,610,000 |
| 48 | 1.10.3 | Acian / skimcoat | 6d | 2025-01-07 | 2025-01-12 | 47 | 0d |  | Tukang [200%]; Pembantu Tukang [300%] | 240h | 4,200,000 |
| 49 | 1.10.4 | Pekerjaan Benangan | 3d | 2025-01-07 | 2025-01-09 | 48SS | 3d | 0d | Tukang [200%]; Pembantu Tukang | 72h | 1,380,000 |
| 50 | 1.10.5 | Waterprofing | 2d | 2025-01-13 | 2025-01-14 | 49, 48 | 0d |  | Mandor; Tukang [200%] | 48h | 1,020,000 |
| 51 | 1.10.6 | Pasang rangka plafon | 1d | 2025-01-15 | 2025-01-15 | 50 | 0d |  | Subkon 3 | 8h | 1,200,000 |
| 52 | 1.10.7 | Plafon gypsum 9 mm + rangka hollow | 2d | 2025-01-16 | 2025-01-17 | 51 | 0d |  |  |  |  |
| 53 | 1.10.8 | Pasang lis shadowline | 1d | 2025-01-18 | 2025-01-18 | 52 | 0d |  |  |  |  |
| 54 | 1.11 | **Pekerjaan Kanopi** | 3d | 2024-12-01 | 2024-12-03 |  | 60d |  |  | 96h | 1,740,000 |
| 55 | 1.11.1 | Pekerjaan kanopi 75% | 3d | 2024-12-01 | 2024-12-03 | 31 | 60d | 0d | Mandor; Tukang; Pembantu Tukang [200%] | 96h | 1,740,000 |
| 56 | 1.12 | **Pekerjaan Pengecatan** | 5d | 2025-01-19 | 2025-01-23 |  | 0d |  |  | 120h | 2,550,000 |
| 57 | 1.12.1 | Pengecetan plafon dan dinding 50% | 5d | 2025-01-19 | 2025-01-23 | 53 | 0d |  | Mandor; Tukang [200%] | 120h | 2,550,000 |

| ID | WBS | Task | Duration | Start | Finish | Predecessors | Total slack | Free slack | Resources | Work | Cost |
| --- | --- | --- | --- | --- | --- | --- | --- | --- | --- | --- | --- |
| 58 | 1.13 | **Pekerjaan Lantai dan cor meja dapur** | 5d | 2025-01-15 | 2025-01-19 |  | 8d |  |  | 176h | 3,290,000 |
| 59 | 1.13.1 | Cor meja dapur | 1d | 2025-01-15 | 2025-01-15 | 50 | 8d | 0d | Tukang; Pembantu Tukang | 16h | 290,000 |
| 60 | 1.13.2 | Pasang granit kramik lantai | 4d | 2025-01-16 | 2025-01-19 | 59 | 15d |  | Mandor; Tukang; Pembantu Tukang | 96h | 1,840,000 |
| 61 | 1.13.3 | Pasang kramik dinding km | 2d | 2025-01-16 | 2025-01-17 | 59 | 17d |  | Tukang; Pembantu Tukang | 32h | 580,000 |
| 62 | 1.13.4 | Pasang kramik lantai km | 1d | 2025-01-16 | 2025-01-16 | 59 | 17d | 0d | Tukang; Pembantu Tukang | 16h | 290,000 |
| 63 | 1.13.5 | Pasang kramik meja dapur | 1d | 2025-01-16 | 2025-01-16 | 59 | 17d | 0d | Tukang; Pembantu Tukang | 16h | 290,000 |
| 64 | 1.14 | **Pekerjaan Fasad Depan** | 11d | 2025-01-16 | 2025-01-26 | 59 | 8d |  |  | 376h | 7,120,000 |
| 65 | 1.14.1 | Pilar dan balok carport | 7d | 2025-01-16 | 2025-01-22 | 34 | 12d | 0d | Mandor; Tukang; Pembantu Tukang | 168h | 3,220,000 |
| 66 | 1.14.2 | Rabat carport dan area taman belakang * | 2d | 2025-01-16 | 2025-01-17 | 65SS | 17d |  | Tukang [200%]; Pembantu Tukang [200%] | 64h | 1,160,000 |
| 67 | 1.14.3 | Pasang batu alam / ornamen fasad | 1d | 2025-01-24 | 2025-01-24 | 56 | 0d |  | Mandor; Tukang; Pembantu Tukang | 24h | 460,000 |
| 68 | 1.14.4 | pembuatan taman depan belakang | 2d | 2025-01-24 | 2025-01-25 | 67SS | 9d |  | Tukang; Pembantu Tukang | 32h | 580,000 |
| 69 | 1.14.5 | Pasangan bata roster teras kanan dan kiri | 1d | 2025-01-24 | 2025-01-24 | 67SS | 0d |  | Tukang [200%]; Pembantu Tukang [200%] | 32h | 580,000 |
| 70 | 1.14.6 | Pasang roster finish | 2d | 2025-01-25 | 2025-01-26 | 69 | 0d |  | Mandor; Tukang; Pembantu Tukang | 48h | 920,000 |
| 71 | 1.14.7 | Pasang conwood | 1d | 2025-01-25 | 2025-01-25 | 70SS | 9d |  | Subkon 2 | 8h | 200,000 |
| 72 | 1.15 | **Pekerjaan Pengecatan** | 3d | 2025-01-27 | 2025-01-29 |  | 0d |  |  | 24h | 510,000 |
| 73 | 1.15.1 | Finishing pengecetan 100% | 3d | 2025-01-27 | 2025-01-29 | 70 | 0d |  | Tukang | 24h | 510,000 |
| 74 | 1.16 | **Pekerjaan Pasang Aksesoris** | 58d | 2024-12-04 | 2025-01-30 |  | 4d |  |  | 112h | 4,600,000 |
| 75 | 1.16.1 | Pasang almini kusen, kaca dan jendela | 4d | 2025-01-10 | 2025-01-13 | 49 | 18d | 0d | Subkon 5 | 32h | 3,000,000 |
| 76 | 1.16.2 | Pasang kanopi | 2d | 2024-12-04 | 2024-12-05 | 55 | 60d |  | Tukang [300%] | 48h | 1,020,000 |
| 77 | 1.16.3 | Pasang pintu | 2d | 2025-01-14 | 2025-01-15 | 75 | 18d | 0d | Subkon 6 | 16h | 240,000 |
| 78 | 1.16.4 | Pasang HPL | 1d | 2025-01-16 | 2025-01-16 | 77 | 18d |  |  |  |  |
| 79 | 1.16.5 | Pasang wastafel | 1d | 2025-01-17 | 2025-01-17 | 63 | 17d |  | Tukang | 8h | 170,000 |
| 80 | 1.16.6 | Pasang closet dan kran | 1d | 2025-01-17 | 2025-01-17 | 62 | 17d |  | Tukang | 8h | 170,000 |
| 81 | 1.16.7 | Pasang asesoris listrik | 1d | 2025-01-30 | 2025-01-30 | 73 | 0d |  |  |  |  |
| 82 | 1.17 | Pembersihan | 4d | 2025-01-31 | 2025-02-03 | 81 | 0d |  | Pembantu Tukang [200%] | 64h | 960,000 |
